# CTAAS Capstone Project_Apr2_2009

Schedule from MS Project, 2009-01-22 to 2010-04-20, A marks actual dates.

## Calendars

- Standard: Mon-Fri 08:00-12:00, 13:00-17:00; Sat-Sun off.

## Resources

| Resource |
| --- |
| Management |
| Project manager |
| Analyst |
| Developer |
| Testers |
| Trainers |
| Technical communicators |
| Deployment team |

## Schedule

| ID | WBS | Task | Type | Duration | Start | Finish | Predecessors | Complete | Remaining | Total slack | Free slack | Constraint | Resources | Work | Actual work |
| --- | --- | --- | --- | --- | --- | --- | --- | --- | --- | --- | --- | --- | --- | --- | --- |
| 1 | 1 | **Project Management** |  | 324d | 2009-01-22 A | 2010-04-20 |  | 93% | 21.42d | 0d |  |  |  | 160h | 160h |
| 2 | 1.1 | **Schedule (Time) Management** |  | 324d | 2009-01-22 A | 2010-04-20 |  | 97% | 11d | 0d |  |  |  | 160h | 160h |
| 3 | 1.1.1 | Activity Definition |  | 11d | 2009-01-22 A | 2009-02-05 A |  | 100% |  |  |  | start no earlier than 2009-01-22 |  | 80h | 80h |
| 4 | 1.1.2 | Activity Sequencing |  | 5d | 2009-02-06 A | 2009-02-12 A | 3 | 100% |  |  |  | start no earlier than 2006-11-06 |  | 40h | 40h |
| 5 | 1.2.2 | Activity Duration Estimating |  | 5d | 2009-02-13 A | 2009-02-19 A | 4 | 100% |  |  |  | start no earlier than 2006-11-16 |  | 40h | 40h |
| 6 | 1.1.4 | Schedule Development |  | 5d | 2009-02-20 A | 2009-02-26 A | 5 | 100% |  |  |  | start no earlier than 2007-01-01 |  |  |  |
| 7 | 1.1.5 | Schedule Control |  | 55d | 2010-02-03 A | 2010-04-20 | 6 | 95% | 2.75d | 0d |  | finish no earlier than 2010-04-20 |  |  |  |
| 8 | 1.2 | **Performance (Quality) Management** |  | 318d | 2009-01-22 A | 2010-04-12 |  | 91% | 29.39d | 6d |  |  |  |  |  |
| 9 | 1.2.1 | Quality Planning |  | 15d | 2009-01-22 A | 2009-02-11 |  | 95% | 0.75d | 304.8d | 261d | start no earlier than 2009-01-22 |  |  |  |
| 10 | 1.2.2 | Quality Assurance |  | 42d | 2010-02-12 A | 2010-04-12 | 9 | 90% | 4.2d | 6d |  | start no earlier than 2010-02-12 |  |  |  |
| 11 | 1.2.3 | Quality Control |  | 42d | 2010-02-12 A | 2010-04-12 | 9 | 90% | 4.2d | 6d |  | start no earlier than 2010-02-12 |  |  |  |
| 12 | 2 | **Problem/Project Identification** |  | 15d | 2009-01-22 A | 2009-02-11 A |  | 100% |  |  |  |  |  | 42h | 42h |
| 13 | 2.1 | Secure project sponsorship |  | 1d | 2009-01-22 A | 2009-01-22 A |  | 100% |  |  |  |  | Management | 8h | 8h |
| 14 | 2.2 | Secure project sponsorship |  | 1d | 2009-01-23 A | 2009-01-23 A | 13 | 100% |  |  |  |  | Management | 8h | 8h |
| 15 | 2.3 | Secure project sponsorship |  | 1d | 2009-01-26 A | 2009-01-26 A | 14 | 100% |  |  |  |  | Management | 8h | 8h |
| 16 | 2.4 | Define Project Organization |  | 2h | 2009-02-11 A | 2009-02-11 A |  | 100% |  |  |  |  | Project manager | 2h | 2h |
| 17 | 2.5 | Define Project Functions |  | 1d | 2009-02-11 A | 2009-02-11 A |  | 100% |  |  |  |  | Project manager | 8h | 8h |
| 18 | 2.6 | Secure core resources |  | 1d | 2009-02-11 A | 2009-02-11 A |  | 100% |  |  |  |  | Project manager | 8h | 8h |
| 19 | 3 | **Scope & Preliminary CONOPS** |  | 12d | 2009-01-27 A | 2009-02-11 A |  | 100% |  |  |  |  |  | 88h | 88h |
| 20 | 3.1 | Determine project scope |  | 11d | 2009-01-27 A | 2009-02-10 A |  | 100% |  |  |  |  | Management | 88h | 88h |
| 21 | 3.2 | Scope complete | milestone | 0d | 2009-02-11 A | 2009-02-11 A |  | 100% |  |  |  |  |  |  |  |
| 22 | 4 | **Literature Review** |  | 5d | 2009-01-23 A | 2009-01-29 A | 12SS | 100% |  |  |  |  |  | 40h | 40h |
| 23 | 4.1 | Identify Relevant sources |  | 2d | 2009-01-23 A | 2009-01-26 A | 13 | 100% |  |  |  |  | Analyst | 16h | 16h |
| 24 | 4.2 | Obtain, Disseminate, & Review Sources |  | 3d | 2009-01-27 A | 2009-01-29 A | 23 | 100% |  |  |  |  | Technical communicators | 24h | 24h |

| ID | WBS | Task | Type | Duration | Start | Finish | Predecessors | Complete | Remaining | Total slack | Free slack | Resources | Work | Actual work |
| --- | --- | --- | --- | --- | --- | --- | --- | --- | --- | --- | --- | --- | --- | --- |
| 25 | 5 | **Analysis/Model Requirements** |  | 5.75d | 2009-02-11 A | 2009-02-18 | 12SS | 97% | 0.19d | 36.54d | 0d |  | 72h | 69.6h |
| 26 | 5.1 | Conduct needs analysis |  | 1d | 2009-02-11 A | 2009-02-11 |  | 95% | 0.05d | 37.61d | 0d | Analyst | 8h | 7.6h |
| 27 | 5.2 | Draft preliminary specifications |  | 2d | 2009-02-12 A | 2009-02-13 | 26 | 95% | 0.1d | 35.88d |  | Analyst | 16h | 15.2h |
| 28 | 5.3 | Develop preliminary budget |  | 4h | 2009-02-16 A | 2009-02-16 A | 27 | 100% |  |  |  | Project manager | 4h | 4h |
| 29 | 5.4 | Review software specifications/budget with team |  | 4h | 2009-02-12 A | 2009-02-12 | 26 | 95% | 0.2h | 37.13d | 0d | Project manager; Analyst | 8h | 7.6h |
| 30 | 5.5 | Incorporate feedback on software specifications |  | 1d | 2009-02-12 A | 2009-02-13 | 29 | 95% | 0.05d | 39.74d | 0d | Analyst | 8h | 7.6h |
| 31 | 5.6 | Develop delivery timeline |  | 1d | 2009-02-13 A | 2009-02-16 | 30 | 95% | 0.05d | 38.79d |  | Project manager | 8h | 7.6h |
| 32 | 5.7 | Obtain approvals to proceed (concept, timeline, budget) |  | 2h | 2009-02-16 A | 2009-02-16 A | 31 | 100% |  |  |  | Management; Project manager | 4h | 4h |
| 33 | 5.8 | Secure required resources |  | 2d | 2009-02-16 A | 2009-02-18 A | 32 | 100% |  |  |  | Project manager | 16h | 16h |
| 34 | 5.9 | Analysis complete | milestone | 0d | 2009-02-18 A | 2009-02-18 | 33 | 95% | 0d | 36.53d | 0d |  |  |  |
| 35 | 6 | **Model Design** |  | 9.25d? | 2009-02-18 A | 2009-03-03 | 25 | 99% | 0.04d? | 27.32d | 0d |  | 76h | 76h |
| 36 | 6.1 | **High Level Model Design** |  | 3.75d? | 2009-02-18 A | 2009-02-24 | 34 | 99% | 0.04d? | 32.83d |  |  | 12h | 12h |
| 37 | 6.1.1 | Review preliminary software specifications |  | 6h | 2009-02-18 A | 2009-02-19 A | 34 | 100% |  |  |  | Analyst | 6h | 6h |
| 38 | 6.1.2 | Develop functional specifications |  | 6h | 2009-02-18 A | 2009-02-19 A | 34 | 100% |  |  |  | Analyst | 6h | 6h |
| 39 | 6.1.3 | Develop Model of Major modules |  | 1d? | 2009-02-19 A | 2009-02-20 | 38 | 95% | 0.05d? | 34.83d |  |  |  |  |
| 40 | 6.1.4 | Perform Form/Function Analysis |  | 1d? | 2009-02-20 A | 2009-02-23 A | 39 | 100% |  |  |  |  |  |  |
| 41 | 6.1.5 | Perform Analysis of Alternatives |  | 1d? | 2009-02-23 A | 2009-02-24 A | 40 | 100% |  |  |  |  |  |  |
| 42 | 6.2 | **Detailed Model Design** |  | 9.25d | 2009-02-18 A | 2009-03-03 A | 41 | 100% |  |  |  |  | 64h | 64h |
| 43 | 6.2.1 | **Data Collection & Analysis** |  | 9.25d | 2009-02-18 A | 2009-03-03 A | 41 | 100% |  |  |  |  | 48h | 48h |
| 44 | 6.2.1.1 | Obtain historical data |  | 2d | 2009-02-18 A | 2009-02-25 A | 41 | 100% |  |  |  | Analyst | 16h | 16h |
| 45 | 6.2.1.2 | Scrub & Format Data |  | 2d | 2009-02-26 A | 2009-02-27 A | 44 | 100% |  |  |  | Analyst | 16h | 16h |
| 46 | 6.2.1.3 | Determine Appropriate Statistical Distributions |  | 2d | 2009-03-02 A | 2009-03-03 A | 45 | 100% |  |  |  | Analyst | 16h | 16h |
| 47 | 6.2.2 | Develop prototype based on functional specifications |  | 2d | 2009-02-26 A | 2009-03-02 A | 46, 40 | 100% |  |  |  | Deployment team | 16h | 16h |
| 48 | 6.3 | Design complete | milestone | 0d | 2009-03-02 A | 2009-03-02 | 41, 47 | 95% | 0d | 25.98d | 0d |  |  |  |

| ID | WBS | Task | Type | Duration | Start | Finish | Predecessors | Complete | Remaining | Total slack | Free slack | Resources | Work | Actual work |
| --- | --- | --- | --- | --- | --- | --- | --- | --- | --- | --- | --- | --- | --- | --- |
| 49 | 7 | **Model Development** |  | 7d | 2009-03-02 A | 2009-03-11 | 48 | 71% | 2d | 289.25d |  |  |  |  |
| 50 | 7.1 | Code Primary Model Modules |  | 2d | 2009-03-02 A | 2009-03-04 A |  | 100% |  |  |  |  |  |  |
| 51 | 7.2 | Code Model Flow Logic |  | 2d | 2009-03-04 A | 2009-03-06 | 50 | 75% | 0.5d | 4.28d | 0d |  |  |  |
| 52 | 7.3 | Code Metric Collection Modules |  | 1d | 2009-03-06 A | 2009-03-09 | 51 | 60% | 0.4d | 3.67d | 0d |  |  |  |
| 53 | 7.4 | Codel Model Optimization Modules |  | 2d | 2009-03-09 A | 2009-03-11 | 52 | 45% | 1.1d | 289.25d |  |  |  |  |
| 54 | 8 | **Test & Validate Design** |  | 8d | 2009-03-09 A | 2009-03-19 |  | 9% | 7.3d | 2.98d |  |  | 80h | 5.6h |
| 55 | 8.1 | Review & Test functional specifications |  | 2d | 2009-03-09 A | 2009-03-11 | 52 | 35% | 1.3d | 2.98d | 0d | Testers | 16h | 5.6h |
| 56 | 8.2 | Present Findings |  | 1d | 2009-03-11 | 2009-03-12 | 55 |  |  | 2.98d | 0d | Analyst | 8h |  |
| 57 | 8.3 | Incorporate feedback into functional specifications |  | 3d | 2009-03-12 | 2009-03-17 | 56 |  |  | 2.98d | 0d | Management | 24h |  |
| 58 | 8.4 | Obtain approval to proceed |  | 2d | 2009-03-17 | 2009-03-19 | 57 |  |  | 2.98d | 0d | Management; Project manager | 32h |  |
| 59 | 9 | **Verify Model Operations** |  | 2.88d | 2009-03-19 | 2009-03-24 | 58 |  |  | 2.98d |  |  | 21h |  |
| 60 | 9.1 | Review functional specifications |  | 3h | 2009-03-19 | 2009-03-20 | 58 |  |  | 2.98d | 0d | Developer | 3h |  |
| 61 | 9.2 | Develop Excursions & Scenarios |  | 2h | 2009-03-20 | 2009-03-20 | 60 |  |  | 2.98d | 0d | Developer | 2h |  |
| 62 | 9.3 | Code Excursions & Scenarios |  | 2h | 2009-03-20 | 2009-03-20 | 61 |  |  | 2.98d | 0d |  |  |  |
| 63 | 9.4 | Run Excursions & Scenarios |  | 2d | 2009-03-20 | 2009-03-24 | 62 |  |  | 2.98d | 0d | Developer | 16h |  |
| 64 | 9.5 | Development complete | milestone | 0d | 2009-03-24 | 2009-03-24 | 63 |  |  | 0.47d | 0d |  |  |  |
| 65 | 10 | **Verify CONOPS based upon Model Results** |  | 2d | 2009-03-24 A | 2009-03-26 | 64 | 19% | 1.62d | 2.6d | 0d |  | 16h | 3h |
| 66 | 10.1 | **Review Model Results** |  | 2d | 2009-03-24 A | 2009-03-26 | 64 | 19% | 1.62d | 2.6d |  |  | 16h | 3h |
| 67 | 10.1.1 | Determine key performance metrics |  | 4h | 2009-03-24 A | 2009-03-25 | 64 | 75% | 1h | 2.6d | 0d | Analyst | 4h | 3h |
| 68 | 10.1.2 | Organize Model Excursions Output Data |  | 4h | 2009-03-25 | 2009-03-25 | 67 |  |  | 2.6d | 0d | Analyst | 4h |  |
| 69 | 10.1.3 | Review & Analyze Model Output |  | 1d | 2009-03-25 | 2009-03-26 | 68 |  |  | 2.6d | 0d | Testers | 8h |  |
| 70 | 11 | **Perform Sensitivity Analysis** |  | 5.5d | 2009-03-26 | 2009-04-03 | 69 |  |  | 2.6d |  | Testers | 64h |  |
| 71 | 11.1 | Perform Regression Analysis |  | 2d | 2009-03-26 | 2009-03-30 | 69 |  |  | 2.6d | 0d | Testers | 16h |  |
| 72 | 11.2 | Develop Excursions Isolating Key Parameters |  | 4h | 2009-03-30 | 2009-03-31 | 71 |  |  | 2.6d | 0d | Testers | 4h |  |
| 73 | 11.3 | Run New Excursions & Document Results |  | 3d | 2009-03-31 | 2009-04-03 | 72 |  |  | 2.6d | 0d |  |  |  |
| 74 | 12 | Review Model Results & Analysis Complete | milestone | 0d | 2009-04-03 | 2009-04-03 | 69, 73 |  |  | 0.4d | 0d |  |  |  |

| ID | WBS | Task | Type | Duration | Start | Finish | Predecessors | Complete | Remaining | Total slack | Free slack | Resources | Work | Actual work |
| --- | --- | --- | --- | --- | --- | --- | --- | --- | --- | --- | --- | --- | --- | --- |
| 75 | 13 | **Documentation** |  | 45d | 2009-01-22 A | 2009-03-25 | 12SS | 71% | 12.96d | 15.12d |  |  | 48h | 17.6h |
| 76 | 13.1 | **Website Development** |  | 45d | 2009-01-22 A | 2009-03-25 | 12SS | 76% | 10.95d | 15.12d |  |  |  |  |
| 77 | 13.1.1 | Obtain Webspace |  | 1d | 2009-01-22 A | 2009-01-22 A |  | 100% |  |  |  |  |  |  |
| 78 | 13.1.2 | Assign Web Maintenance Team |  | 2h | 2009-01-22 A | 2009-01-22 A |  | 100% |  |  |  |  |  |  |
| 79 | 13.1.3 | Maintain Website |  | 45d | 2009-01-22 A | 2009-03-25 |  | 75% | 11.25d | 15.12d | 0d |  |  |  |
| 80 | 13.2 | **User/Sponsor Documentation** |  | 6d | 2009-03-04 A | 2009-03-11 | 35 | 37% | 3.8d | 25.12d |  |  | 48h | 17.6h |
| 81 | 13.2.1 | Outline user manuals specifications |  | 2d | 2009-03-04 A | 2009-03-05 | 48 | 40% | 1.2d | 26.52d | 0d | Technical communicators | 16h | 6.4h |
| 82 | 13.2.2 | Review all user documentation |  | 2d | 2009-03-06 A | 2009-03-09 | 81 | 40% | 1.2d | 25.73d | 0d | Technical communicators | 16h | 6.4h |
| 83 | 13.2.3 | Incorporate user documentation feedback |  | 2d | 2009-03-10 A | 2009-03-11 | 82 | 30% | 1.4d | 25.12d | 10d | Technical communicators | 16h | 4.8h |
| 84 | 13.3 | Documentation complete | milestone | 0d | 2009-03-25 | 2009-03-25 | 83, 79 |  |  | 15.12d |  |  |  |  |
| 85 | 14 | **Finalize System CONOPs** |  | 14.5d | 2009-03-26 A | 2009-04-16 | 65 | 51% | 7.12d | 0d |  |  | 80h | 39.2h |
| 86 | 14.1 | Identify Pilot Entity |  | 1d | 2009-03-26 A | 2009-03-27 | 48 | 80% | 0.2d | 8.3d | 0d | Project manager | 8h | 6.4h |
| 87 | 14.2 | Develop implementation plan |  | 1d | 2009-03-27 A | 2009-03-30 | 86 | 70% | 0.3d | 7.6d | 3.5d |  |  |  |
| 88 | 14.3 | **Integration Test Plan** |  | 4d | 2009-04-03 A | 2009-04-09 | 65, 87 | 65% | 1.4d | 1.5d | 0d |  | 32h | 20.8h |
| 89 | 14.3.1 | Develop integration plan specifications |  | 4d | 2009-04-03 A | 2009-04-09 | 48, 74 | 65% | 1.4d | 0d |  | Testers | 32h | 20.8h |
| 90 | 14.3.2 | Integration testing complete | milestone | 0d | 2009-04-09 A | 2009-04-09 | 89 | 20% | 0d | 1.5d |  |  |  |  |
| 91 | 14.4 | Obtain user feedback |  | 1w | 2009-04-09 A | 2009-04-16 | 88 | 30% | 0.7w | 0d |  | Deployment team | 40h | 12h |
| 92 | 14.5 | Pilot complete | milestone | 0d | 2009-04-16 | 2009-04-16 | 91 |  |  | 0d |  |  |  |  |
| 93 | 15 | **Final Report & Presentation** |  | 5d | 2009-04-16 A | 2009-04-23 | 12, 22, 25, 35, 59, 65, 75, 85, 88 | 44% | 2.82d | 258.88d |  |  | 72h | 50.26h |
| 94 | 15.1 | **Final Report Development** |  | 3d | 2009-04-16 A | 2009-04-21 |  | 36% | 1.92d | 260.88d |  | Project manager | 48h | 26.26h |
| 95 | 15.1.1 | Develop Template |  | 1d | 2009-04-16 A | 2009-04-17 A |  | 100% |  |  |  | Project manager | 8h | 8h |
| 96 | 15.1.2 | Draft Boilerplate Information(Scope, Problem, Org, Task, etc.) |  | 2d | 2009-04-16 A | 2009-04-20 | 21 | 60% | 0.8d | 0d |  | Project manager | 16h | 9.6h |
| 97 | 15.1.3 | Draft Project Methodology |  | 2d | 2009-04-16 A | 2009-04-20 | 34 | 45% | 1.1d | 261.88d |  |  |  |  |
| 98 | 15.1.4 | Draft Project Specifications |  | 2d | 2009-04-16 A | 2009-04-20 | 48 | 40% | 1.2d | 261.88d |  |  |  |  |
| 99 | 15.1.5 | Draft Initial Model Results |  | 2d | 2009-04-16 | 2009-04-20 | 64 |  |  | 261.88d |  |  |  |  |
| 100 | 15.1.6 | Draft Model Analysis Section |  | 3d | 2009-04-16 | 2009-04-21 | 74 |  |  | 260.88d |  |  |  |  |
| 101 | 15.1.7 | Add Integretion Plans |  | 1d | 2009-04-16 A | 2009-04-17 | 90 | 70% | 0.3d | 262.88d |  |  |  |  |
| 102 | 15.1.8 | Add User Documentation |  | 1d | 2009-04-16 A | 2009-04-17 | 84 | 45% | 0.55d | 262.88d | 2d |  |  |  |

| ID | WBS | Task | Type | Duration | Start | Finish | Predecessors | Complete | Remaining | Total slack | Free slack | Resources | Work | Actual work |
| --- | --- | --- | --- | --- | --- | --- | --- | --- | --- | --- | --- | --- | --- | --- |
| 103 | 15.2 | **Final Presentation Development** |  | 3d | 2009-04-20 A | 2009-04-23 | 96 | 51% | 1.47d | 258.88d |  |  | 24h | 24h |
| 104 | 15.2.1 | Develop Template |  | 1d | 2009-04-20 A | 2009-04-21 A |  | 100% |  |  |  | Project manager | 8h | 8h |
| 105 | 15.2.2 | Draft Boilerplate Information(Scope, Problem, Org, Task, etc.) |  | 2d | 2009-04-20 A | 2009-04-22 A | 21 | 100% |  |  |  | Project manager | 16h | 16h |
| 106 | 15.2.3 | Draft Project Methodology |  | 2d | 2009-04-20 A | 2009-04-22 | 34 | 75% | 0.5d | 259.88d |  |  |  |  |
| 107 | 15.2.4 | Draft Project Specifications |  | 2d | 2009-04-20 A | 2009-04-22 | 48 | 75% | 0.5d | 259.88d |  |  |  |  |
| 108 | 15.2.5 | Draft Initial Model Results |  | 2d | 2009-04-20 A | 2009-04-22 | 64 | 20% | 1.6d | 259.88d |  |  |  |  |
| 109 | 15.2.6 | Draft Model Analysis Section |  | 3d | 2009-04-20 | 2009-04-23 | 74 |  |  | 258.88d |  |  |  |  |
| 110 | 15.2.7 | Add Integretion Plans |  | 1d | 2009-04-20 A | 2009-04-21 | 90 | 40% | 0.6d | 260.88d |  |  |  |  |
| 111 | 15.2.8 | Add User Documentation |  | 1d | 2009-04-20 A | 2009-04-21 | 84 | 35% | 0.65d | 260.88d | 0d |  |  |  |
| 112 | 15.3 | Final Report & Presentation complete | milestone | 0d | 2009-04-21 | 2009-04-21 | 111, 102 |  |  | 260.88d |  |  |  |  |
