# CTAAS Capstone Project_Mar25_2009

Schedule from MS Project, 2009-01-22 to 2010-04-20, A marks actual dates.

## Calendars

- Standard: Mon-Fri 08:00-12:00, 13:00-17:00; Sat-Sun off.

## Resources

| Resource |
| --- |
| Management |
| Project manager |
| Analyst |
| Developer |
| Testers |
| Trainers |
| Technical communicators |
| Deployment team |

## Schedule

| ID | WBS | Task | Type | Duration | Start | Finish | Predecessors | Complete | Remaining | Total slack | Free slack | Constraint | Resources | Work | Actual work |
| --- | --- | --- | --- | --- | --- | --- | --- | --- | --- | --- | --- | --- | --- | --- | --- |
| 1 | 1 | **Project Management** |  | 324d | 2009-01-22 A | 2010-04-20 |  | 93% | 21.42d | 0d |  |  |  | 160h | 160h |
| 2 | 1.1 | **Schedule (Time) Management** |  | 324d | 2009-01-22 A | 2010-04-20 |  | 97% | 11d | 0d |  |  |  | 160h | 160h |
| 3 | 1.1.1 | Activity Definition |  | 11d | 2009-01-22 A | 2009-02-05 A |  | 100% |  |  |  | start no earlier than 2009-01-22 |  | 80h | 80h |
| 4 | 1.1.2 | Activity Sequencing |  | 5d | 2009-02-06 A | 2009-02-12 A | 3 | 100% |  |  |  | start no earlier than 2006-11-06 |  | 40h | 40h |
| 5 | 1.2.2 | Activity Duration Estimating |  | 5d | 2009-02-13 A | 2009-02-19 A | 4 | 100% |  |  |  | start no earlier than 2006-11-16 |  | 40h | 40h |
| 6 | 1.1.4 | Schedule Development |  | 5d | 2009-02-20 A | 2009-02-26 A | 5 | 100% |  |  |  | start no earlier than 2007-01-01 |  |  |  |
| 7 | 1.1.5 | Schedule Control |  | 55d | 2010-02-03 A | 2010-04-20 | 6 | 95% | 2.75d | 0d |  | finish no earlier than 2010-04-20 |  |  |  |
| 8 | 1.2 | **Performance (Quality) Management** |  | 318d | 2009-01-22 A | 2010-04-12 |  | 91% | 29.39d | 6d |  |  |  |  |  |
| 9 | 1.2.1 | Quality Planning |  | 15d | 2009-01-22 A | 2009-02-11 |  | 95% | 0.75d | 304.8d | 261d | start no earlier than 2009-01-22 |  |  |  |
| 10 | 1.2.2 | Quality Assurance |  | 42d | 2010-02-12 A | 2010-04-12 | 9 | 90% | 4.2d | 6d |  | start no earlier than 2010-02-12 |  |  |  |
| 11 | 1.2.3 | Quality Control |  | 42d | 2010-02-12 A | 2010-04-12 | 9 | 90% | 4.2d | 6d |  | start no earlier than 2010-02-12 |  |  |  |
| 12 | 2 | **Problem/Project Identification** |  | 15d | 2009-01-22 A | 2009-02-11 A |  | 100% |  |  |  |  |  | 42h | 42h |
| 13 | 2.1 | Secure project sponsorship |  | 1d | 2009-01-22 A | 2009-01-22 A |  | 100% |  |  |  |  | Management | 8h | 8h |
| 14 | 2.2 | Secure project sponsorship |  | 1d | 2009-01-23 A | 2009-01-23 A | 13 | 100% |  |  |  |  | Management | 8h | 8h |
| 15 | 2.3 | Secure project sponsorship |  | 1d | 2009-01-26 A | 2009-01-26 A | 14 | 100% |  |  |  |  | Management | 8h | 8h |
| 16 | 2.4 | Define Project Organization |  | 2h | 2009-02-11 A | 2009-02-11 A |  | 100% |  |  |  |  | Project manager | 2h | 2h |
| 17 | 2.5 | Define Project Functions |  | 1d | 2009-02-11 A | 2009-02-11 A |  | 100% |  |  |  |  | Project manager | 8h | 8h |
| 18 | 2.6 | Secure core resources |  | 1d | 2009-02-11 A | 2009-02-11 A |  | 100% |  |  |  |  | Project manager | 8h | 8h |
| 19 | 3 | **Scope & Preliminary CONOPS** |  | 12d | 2009-01-27 A | 2009-02-11 A |  | 100% |  |  |  |  |  | 88h | 88h |
| 20 | 3.1 | Determine project scope |  | 11d | 2009-01-27 A | 2009-02-10 A |  | 100% |  |  |  |  | Management | 88h | 88h |
| 21 | 3.2 | Scope complete | milestone | 0d | 2009-02-11 A | 2009-02-11 A |  | 100% |  |  |  |  |  |  |  |
| 22 | 4 | **Literature Review** |  | 5d | 2009-01-23 A | 2009-01-29 A | 12SS | 100% |  |  |  |  |  | 40h | 40h |
| 23 | 4.1 | Identify Relevant sources |  | 2d | 2009-01-23 A | 2009-01-26 A | 13 | 100% |  |  |  |  | Analyst | 16h | 16h |
| 24 | 4.2 | Obtain, Disseminate, & Review Sources |  | 3d | 2009-01-27 A | 2009-01-29 A | 23 | 100% |  |  |  |  | Technical communicators | 24h | 24h |

| ID | WBS | Task | Type | Duration | Start | Finish | Predecessors | Complete | Remaining | Total slack | Free slack | Resources | Work | Actual work |
| --- | --- | --- | --- | --- | --- | --- | --- | --- | --- | --- | --- | --- | --- | --- |
| 25 | 5 | **Analysis/Model Requirements** |  | 5.75d | 2009-02-11 A | 2009-02-18 | 12SS | 94% | 0.33d | 34.75d | 0d |  | 72h | 68h |
| 26 | 5.1 | Conduct needs analysis |  | 1d | 2009-02-11 A | 2009-02-11 |  | 95% | 0.05d | 37.61d | 0d | Analyst | 8h | 7.6h |
| 27 | 5.2 | Draft preliminary specifications |  | 2d | 2009-02-12 A | 2009-02-13 | 26 | 95% | 0.1d | 35.88d |  | Analyst | 16h | 15.2h |
| 28 | 5.3 | Develop preliminary budget |  | 4h | 2009-02-16 A | 2009-02-16 A | 27 | 100% |  |  |  | Project manager | 4h | 4h |
| 29 | 5.4 | Review software specifications/budget with team |  | 4h | 2009-02-12 A | 2009-02-12 | 26 | 95% | 0.2h | 37.13d | 0d | Project manager; Analyst | 8h | 7.6h |
| 30 | 5.5 | Incorporate feedback on software specifications |  | 1d | 2009-02-12 A | 2009-02-13 | 29 | 90% | 0.1d | 37.9d | 0d | Analyst | 8h | 7.2h |
| 31 | 5.6 | Develop delivery timeline |  | 1d | 2009-02-13 A | 2009-02-16 | 30 | 90% | 0.1d | 37d |  | Project manager | 8h | 7.2h |
| 32 | 5.7 | Obtain approvals to proceed (concept, timeline, budget) |  | 2h | 2009-02-16 A | 2009-02-16 A | 31 | 100% |  |  |  | Management; Project manager | 4h | 4h |
| 33 | 5.8 | Secure required resources |  | 2d | 2009-02-16 A | 2009-02-18 | 32 | 95% | 0.1d | 0d |  | Project manager | 16h | 15.2h |
| 34 | 5.9 | Analysis complete | milestone | 0d | 2009-02-18 A | 2009-02-18 | 33 | 95% | 0d | 34.75d | 0d |  |  |  |
| 35 | 6 | **Model Design** |  | 9.25d? | 2009-02-18 A | 2009-03-03 | 25 | 98% | 0.22d? | 26.62d | 0d |  | 76h | 74.4h |
| 36 | 6.1 | **High Level Model Design** |  | 3.75d? | 2009-02-18 A | 2009-02-24 | 34 | 98% | 0.08d? | 32.12d |  |  | 12h | 12h |
| 37 | 6.1.1 | Review preliminary software specifications |  | 6h | 2009-02-18 A | 2009-02-19 A | 34 | 100% |  |  |  | Analyst | 6h | 6h |
| 38 | 6.1.2 | Develop functional specifications |  | 6h | 2009-02-18 A | 2009-02-19 A | 34 | 100% |  |  |  | Analyst | 6h | 6h |
| 39 | 6.1.3 | Develop Model of Major modules |  | 1d? | 2009-02-19 A | 2009-02-20 | 38 | 90% | 0.1d? | 33.23d |  |  |  |  |
| 40 | 6.1.4 | Perform Form/Function Analysis |  | 1d? | 2009-02-20 A | 2009-02-23 A | 39 | 100% |  |  |  |  |  |  |
| 41 | 6.1.5 | Perform Analysis of Alternatives |  | 1d? | 2009-02-23 A | 2009-02-24 A | 40 | 100% |  |  |  |  |  |  |
| 42 | 6.2 | **Detailed Model Design** |  | 9.25d | 2009-02-18 A | 2009-03-03 | 41 | 98% | 0.23d | 25.73d |  |  | 64h | 62.4h |
| 43 | 6.2.1 | **Data Collection & Analysis** |  | 9.25d | 2009-02-18 A | 2009-03-03 | 41 | 97% | 0.31d | 25.73d |  |  | 48h | 46.4h |
| 44 | 6.2.1.1 | Obtain historical data |  | 2d | 2009-02-18 A | 2009-02-25 A | 41 | 100% |  |  |  | Analyst | 16h | 16h |
| 45 | 6.2.1.2 | Scrub & Format Data |  | 2d | 2009-02-26 A | 2009-02-27 A | 44 | 100% |  |  |  | Analyst | 16h | 16h |
| 46 | 6.2.1.3 | Determine Appropriate Statistical Distributions |  | 2d | 2009-03-02 A | 2009-03-03 | 45 | 90% | 0.2d | 25.73d |  | Analyst | 16h | 14.4h |
| 47 | 6.2.2 | Develop prototype based on functional specifications |  | 2d | 2009-02-26 A | 2009-03-02 A | 46, 40 | 100% |  |  |  | Deployment team | 16h | 16h |
| 48 | 6.3 | Design complete | milestone | 0d | 2009-03-02 A | 2009-03-02 | 41, 47 | 95% | 0d | 21.88d | 0d |  |  |  |

| ID | WBS | Task | Type | Duration | Start | Finish | Predecessors | Complete | Remaining | Total slack | Free slack | Resources | Work | Actual work |
| --- | --- | --- | --- | --- | --- | --- | --- | --- | --- | --- | --- | --- | --- | --- |
| 49 | 7 | **Model Development** |  | 7d | 2009-03-02 A | 2009-03-11 | 48 | 60% | 2.8d | 289.25d |  |  |  |  |
| 50 | 7.1 | Code Primary Model Modules |  | 2d | 2009-03-02 A | 2009-03-04 |  | 85% | 0.3d | 2.77d | 0d |  |  |  |
| 51 | 7.2 | Code Model Flow Logic |  | 2d | 2009-03-04 A | 2009-03-06 | 50 | 70% | 0.6d | 1.38d | 0d |  |  |  |
| 52 | 7.3 | Code Metric Collection Modules |  | 1d | 2009-03-06 A | 2009-03-09 | 51 | 50% | 0.5d | 0.88d | 0d |  |  |  |
| 53 | 7.4 | Codel Model Optimization Modules |  | 2d | 2009-03-09 A | 2009-03-11 | 52 | 30% | 1.4d | 289.25d |  |  |  |  |
| 54 | 8 | **Test & Validate Design** |  | 8d | 2009-03-09 A | 2009-03-19 |  | 5% | 7.6d | 0.47d |  |  | 80h | 3.2h |
| 55 | 8.1 | Review & Test functional specifications |  | 2d | 2009-03-09 A | 2009-03-11 | 52 | 20% | 1.6d | 0.47d | 0d | Testers | 16h | 3.2h |
| 56 | 8.2 | Present Findings |  | 1d | 2009-03-11 | 2009-03-12 | 55 |  |  | 0.47d | 0d | Analyst | 8h |  |
| 57 | 8.3 | Incorporate feedback into functional specifications |  | 3d | 2009-03-12 | 2009-03-17 | 56 |  |  | 0.47d | 0d | Management | 24h |  |
| 58 | 8.4 | Obtain approval to proceed |  | 2d | 2009-03-17 | 2009-03-19 | 57 |  |  | 0.47d | 0d | Management; Project manager | 32h |  |
| 59 | 9 | **Verify Model Operations** |  | 2.88d | 2009-03-19 | 2009-03-24 | 58 |  |  | 0.47d | 16.5d |  | 21h |  |
| 60 | 9.1 | Review functional specifications |  | 3h | 2009-03-19 | 2009-03-20 | 58 |  |  | 0.47d | 0d | Developer | 3h |  |
| 61 | 9.2 | Develop Excursions & Scenarios |  | 2h | 2009-03-20 | 2009-03-20 | 60 |  |  | 0.47d | 0d | Developer | 2h |  |
| 62 | 9.3 | Code Excursions & Scenarios |  | 2h | 2009-03-20 | 2009-03-20 | 61 |  |  | 0.47d | 0d |  |  |  |
| 63 | 9.4 | Run Excursions & Scenarios |  | 2d | 2009-03-20 | 2009-03-24 | 62 |  |  | 0.47d | 0d | Developer | 16h |  |
| 64 | 9.5 | Development complete | milestone | 0d | 2009-03-24 | 2009-03-24 | 63 |  |  | 0.47d | 0d |  |  |  |
| 65 | 10 | **Verify CONOPS based upon Model Results** |  | 2d | 2009-03-24 A | 2009-03-26 | 64 | 4% | 1.93d | 2.7d | 0d |  | 16h | 0.6h |
| 66 | 10.1 | **Review Model Results** |  | 2d | 2009-03-24 A | 2009-03-26 | 64 | 4% | 1.93d | 2.7d |  |  | 16h | 0.6h |
| 67 | 10.1.1 | Determine key performance metrics |  | 4h | 2009-03-24 A | 2009-03-25 | 64 | 15% | 3.4h | 2.7d | 0d | Analyst | 4h | 0.6h |
| 68 | 10.1.2 | Organize Model Excursions Output Data |  | 4h | 2009-03-25 | 2009-03-25 | 67 |  |  | 2.7d | 0d | Analyst | 4h |  |
| 69 | 10.1.3 | Review & Analyze Model Output |  | 1d | 2009-03-25 | 2009-03-26 | 68 |  |  | 2.7d | 0d | Testers | 8h |  |
| 70 | 11 | **Perform Sensitivity Analysis** |  | 5.5d | 2009-03-26 | 2009-04-03 | 69 |  |  | 0.4d |  | Testers | 64h |  |
| 71 | 11.1 | Perform Regression Analysis |  | 2d | 2009-03-26 | 2009-03-30 | 69 |  |  | 0.4d | 0d | Testers | 16h |  |
| 72 | 11.2 | Develop Excursions Isolating Key Parameters |  | 4h | 2009-03-30 | 2009-03-31 | 71 |  |  | 0.4d | 0d | Testers | 4h |  |
| 73 | 11.3 | Run New Excursions & Document Results |  | 3d | 2009-03-31 | 2009-04-03 | 72 |  |  | 0.4d | 0d |  |  |  |
| 74 | 12 | Review Model Results & Analysis Complete | milestone | 0d | 2009-04-03 | 2009-04-03 | 69, 73 |  |  | 0.4d | 0d |  |  |  |

| ID | WBS | Task | Type | Duration | Start | Finish | Predecessors | Complete | Remaining | Total slack | Free slack | Resources | Work | Actual work |
| --- | --- | --- | --- | --- | --- | --- | --- | --- | --- | --- | --- | --- | --- | --- |
| 75 | 13 | **Documentation** |  | 45d | 2009-01-22 A | 2009-03-25 | 12SS | 66% | 15.5d | 15.12d |  |  | 48h | 12h |
| 76 | 13.1 | **Website Development** |  | 45d | 2009-01-22 A | 2009-03-25 | 12SS | 71% | 13.14d | 15.12d |  |  |  |  |
| 77 | 13.1.1 | Obtain Webspace |  | 1d | 2009-01-22 A | 2009-01-22 A |  | 100% |  |  |  |  |  |  |
| 78 | 13.1.2 | Assign Web Maintenance Team |  | 2h | 2009-01-22 A | 2009-01-22 A |  | 100% |  |  |  |  |  |  |
| 79 | 13.1.3 | Maintain Website |  | 45d | 2009-01-22 A | 2009-03-25 |  | 70% | 13.5d | 15.12d | 0d |  |  |  |
| 80 | 13.2 | **User/Sponsor Documentation** |  | 6d | 2009-03-04 A | 2009-03-11 | 35 | 25% | 4.5d | 25.12d |  |  | 48h | 12h |
| 81 | 13.2.1 | Outline user manuals specifications |  | 2d | 2009-03-04 A | 2009-03-05 | 48 | 25% | 1.5d | 26.12d | 0d | Technical communicators | 16h | 4h |
| 82 | 13.2.2 | Review all user documentation |  | 2d | 2009-03-06 A | 2009-03-09 | 81 | 25% | 1.5d | 25.62d | 0d | Technical communicators | 16h | 4h |
| 83 | 13.2.3 | Incorporate user documentation feedback |  | 2d | 2009-03-10 A | 2009-03-11 | 82 | 25% | 1.5d | 25.12d | 10d | Technical communicators | 16h | 4h |
| 84 | 13.3 | Documentation complete | milestone | 0d | 2009-03-25 | 2009-03-25 | 83, 79 |  |  | 15.12d |  |  |  |  |
| 85 | 14 | **Finalize System CONOPs** |  | 14.5d | 2009-03-26 A | 2009-04-16 | 65 | 34% | 9.62d | 0d |  |  | 80h | 26.4h |
| 86 | 14.1 | Identify Pilot Entity |  | 1d | 2009-03-26 A | 2009-03-27 | 48 | 60% | 0.4d | 6.6d | 0d | Project manager | 8h | 4.8h |
| 87 | 14.2 | Develop implementation plan |  | 1d | 2009-03-27 A | 2009-03-30 | 86 | 40% | 0.6d | 6.2d | 3.5d |  |  |  |
| 88 | 14.3 | **Integration Test Plan** |  | 4d | 2009-04-03 A | 2009-04-09 | 65, 87 | 30% | 2.8d | 1.5d | 0d |  | 32h | 9.6h |
| 89 | 14.3.1 | Develop integration plan specifications |  | 4d | 2009-04-03 A | 2009-04-09 | 48, 74 | 30% | 2.8d | 1.5d | 0d | Testers | 32h | 9.6h |
| 90 | 14.3.2 | Integration testing complete | milestone | 0d | 2009-04-09 | 2009-04-09 | 89 |  |  | 1.5d | 5d |  |  |  |
| 91 | 14.4 | Obtain user feedback |  | 1w | 2009-04-09 A | 2009-04-16 | 88 | 30% | 0.7w | 0d |  | Deployment team | 40h | 12h |
| 92 | 14.5 | Pilot complete | milestone | 0d | 2009-04-16 | 2009-04-16 | 91 |  |  | 0d |  |  |  |  |
| 93 | 15 | **Final Report & Presentation** |  | 5d | 2009-04-16 A | 2009-04-23 | 12, 22, 25, 35, 59, 65, 75, 85, 88 | 35% | 3.23d | 258.88d |  |  | 72h | 44.28h |
| 94 | 15.1 | **Final Report Development** |  | 3d | 2009-04-16 A | 2009-04-21 |  | 28% | 2.16d | 260.88d |  | Project manager | 48h | 23.48h |
| 95 | 15.1.1 | Develop Template |  | 1d | 2009-04-16 A | 2009-04-17 A |  | 100% |  |  |  | Project manager | 8h | 8h |
| 96 | 15.1.2 | Draft Boilerplate Information(Scope, Problem, Org, Task, etc.) |  | 2d | 2009-04-16 A | 2009-04-20 | 21 | 55% | 0.9d | 0d |  | Project manager | 16h | 8.8h |
| 97 | 15.1.3 | Draft Project Methodology |  | 2d | 2009-04-16 A | 2009-04-20 | 34 | 35% | 1.3d | 261.88d |  |  |  |  |
| 98 | 15.1.4 | Draft Project Specifications |  | 2d | 2009-04-16 A | 2009-04-20 | 48 | 25% | 1.5d | 261.88d |  |  |  |  |
| 99 | 15.1.5 | Draft Initial Model Results |  | 2d | 2009-04-16 | 2009-04-20 | 64 |  |  | 261.88d |  |  |  |  |
| 100 | 15.1.6 | Draft Model Analysis Section |  | 3d | 2009-04-16 | 2009-04-21 | 74 |  |  | 260.88d |  |  |  |  |
| 101 | 15.1.7 | Add Integretion Plans |  | 1d | 2009-04-16 A | 2009-04-17 | 90 | 35% | 0.65d | 262.88d |  |  |  |  |
| 102 | 15.1.8 | Add User Documentation |  | 1d | 2009-04-16 A | 2009-04-17 | 84 | 25% | 0.75d | 262.88d | 2d |  |  |  |

| ID | WBS | Task | Type | Duration | Start | Finish | Predecessors | Complete | Remaining | Total slack | Free slack | Resources | Work | Actual work |
| --- | --- | --- | --- | --- | --- | --- | --- | --- | --- | --- | --- | --- | --- | --- |
| 103 | 15.2 | **Final Presentation Development** |  | 3d | 2009-04-20 A | 2009-04-23 | 96 | 43% | 1.71d | 258.88d |  |  | 24h | 20.8h |
| 104 | 15.2.1 | Develop Template |  | 1d | 2009-04-20 A | 2009-04-21 A |  | 100% |  |  |  | Project manager | 8h | 8h |
| 105 | 15.2.2 | Draft Boilerplate Information(Scope, Problem, Org, Task, etc.) |  | 2d | 2009-04-20 A | 2009-04-22 | 21 | 80% | 0.4d | 259.88d |  | Project manager | 16h | 12.8h |
| 106 | 15.2.3 | Draft Project Methodology |  | 2d | 2009-04-20 A | 2009-04-22 | 34 | 75% | 0.5d | 259.88d |  |  |  |  |
| 107 | 15.2.4 | Draft Project Specifications |  | 2d | 2009-04-20 A | 2009-04-22 | 48 | 75% | 0.5d | 259.88d |  |  |  |  |
| 108 | 15.2.5 | Draft Initial Model Results |  | 2d | 2009-04-20 A | 2009-04-22 | 64 | 20% | 1.6d | 259.88d |  |  |  |  |
| 109 | 15.2.6 | Draft Model Analysis Section |  | 3d | 2009-04-20 | 2009-04-23 | 74 |  |  | 258.88d |  |  |  |  |
| 110 | 15.2.7 | Add Integretion Plans |  | 1d | 2009-04-20 | 2009-04-21 | 90 |  |  | 260.88d |  |  |  |  |
| 111 | 15.2.8 | Add User Documentation |  | 1d | 2009-04-20 | 2009-04-21 | 84 |  |  | 260.88d | 0d |  |  |  |
| 112 | 15.3 | Final Report & Presentation complete | milestone | 0d | 2009-04-21 | 2009-04-21 | 111, 102 |  |  | 260.88d |  |  |  |  |
